# Mid-Term

Schedule from MS Project, 2013-09-30 to 2014-02-11.
Hewlett-Packard

## Calendars

- Standard: Mon-Fri 08:00-12:00, 13:00-17:00; Sat 08:00-17:00; Sun off.

## Resources

| Resource |
| --- |
| Project Manage |
| Project Manager and Attendee |
| Project Manager and Worker |
| Project Manager and East Side Framing PM |
| Project Manager and Sparks Electrical PM |
| Project Manager and Waterworks Plumbing PM |
| Project Manager and Woodcraft Carpentry PM |
| Project Manager and Student Workers Manger |
| Sparks Electrical PM |
| Waterworks Plumbing PM |
| East Side Framing & Drywall PM |
| East Side Framing & Drywal |
| City & Count |
| Sparks Electrica |
| Waterworks Plumbin |
| Woodcraft Carpentry PM |
| Woodcraft Carpentr |
| Student Workers Manage |
| Student Worker |
| City Equipment Movers PM |
| City Equipment Mover |
| Express Moving Company P |
| Express Moving Company |
| Project Manager |
| Sparks Electrical |
| Waterworks Plumbing |
| East Side Framing & Drywall |
| Woodcraft Carpentry |
| Student Workers |
| City Equipment Movers |
| Express Moving Company PM |
| City & County |
| Project Manager and Workers |
| Project Manager and Attendees |

## Schedule

| ID | WBS | Task | Duration | Start | Finish | Predecessors | Total slack | Free slack | Constraint | Resources | Work |
| --- | --- | --- | --- | --- | --- | --- | --- | --- | --- | --- | --- |
| 1 | 1 | **Project Kick-off** | 4d | 2013-09-30 | 2013-10-03 |  | 93d |  |  |  | 32h |
| 2 | 1.1 | Book location for meeting | 1d | 2013-09-30 | 2013-09-30 |  | 93d | 0d | start no earlier than 2013-09-30 | Project Manager | 8h |
| 3 | 1.2 | Invite stakeholders | 1d | 2013-10-01 | 2013-10-01 | 2 | 93d | 0d |  | Project Manager | 8h |
| 4 | 1.3 | Prepare presentation | 1d | 2013-10-02 | 2013-10-02 | 3 | 93d | 0d |  | Project Manager | 8h |
| 5 | 1.4 | Conduct the meeting | 1d | 2013-10-03 | 2013-10-03 | 4 | 93d | 0d |  | Project Manager and Attendees | 8h |
| 6 | 2 | **Project Document** | 13d | 2013-10-04 | 2013-10-18 |  | 93d |  |  |  | 104h |
| 7 | 2.1 | Develop Charter/Scope | 2d | 2013-10-04 | 2013-10-05 | 5 | 93d | 0d |  | Project Manager | 16h |
| 8 | 2.2 | Develop WBS | 7d | 2013-10-05 | 2013-10-14 | 7 | 93d | 0d |  | Project Manager and Workers | 56h |
| 9 | 2.3 | Develop Project Plan | 2d | 2013-10-14 | 2013-10-16 | 8 | 93d | 0d |  | Project Manager | 16h |
| 10 | 2.4 | Develop Communication Plan | 2d | 2013-10-16 | 2013-10-18 | 9 | 93d | 0d |  | Project Manager | 16h |
| 11 | 3 | **Status Reports/Meetings** | 3d | 2013-10-18 | 2013-10-22 |  | 93d |  |  |  | 24h |
| 12 | 3.1 | Develop Status Report | 1d | 2013-10-18 | 2013-10-19 | 10 | 93d | 0d |  | Project Manager | 8h |
| 13 | 3.2 | Set schedule for team meetings | 1d | 2013-10-19 | 2013-10-21 | 12 | 93d | 0d |  | Project Manager | 8h |
| 14 | 3.4 | Set schedule for stakeholder meetings | 1d | 2013-10-21 | 2013-10-22 | 13 | 93d | 0d |  | Project Manager | 8h |
| 15 | 4 | **Initial Planning Meetings with Vendors** | 5d | 2013-10-22 | 2013-10-28 |  | 93d |  |  |  | 40h |
| 16 | 4.1 | Meet with Framing/Drywall | 1d | 2013-10-22 | 2013-10-23 | 14 | 93d | 0d |  | Project Manager and East Side Framing PM | 8h |
| 17 | 4.2 | Meet with Electrical | 1d | 2013-10-23 | 2013-10-24 | 16 | 93d | 0d |  | Project Manager and Sparks Electrical PM | 8h |
| 18 | 4.3 | Meet with Plumbing | 1d | 2013-10-24 | 2013-10-25 | 17 | 93d | 0d |  | Project Manager and Waterworks Plumbing PM | 8h |
| 19 | 4.4 | Meet with Finish Work | 1d | 2013-10-25 | 2013-10-26 | 18 | 93d | 0d |  | Project Manager and Woodcraft Carpentry PM | 8h |
| 20 | 4.5 | Meet with Student Worker | 1d | 2013-10-26 | 2013-10-28 | 19 | 93d |  |  | Project Manager and Student Workers Manger | 8h |
| 21 | 5 | **Electrical Permits** | 10d | 2013-09-30 | 2013-10-10 |  | 0d |  |  |  | 80h |
| 22 | 5.1 | Obtain Electrical Permit | 10d | 2013-09-30 | 2013-10-10 |  | 0d |  |  | Sparks Electrical PM | 80h |
| 23 | 6 | **Plumbing Permits** | 10d | 2013-09-30 | 2013-10-10 |  | 0d |  |  |  | 80h |
| 24 | 6.1 | Obtain Plumbing Permit | 10d | 2013-09-30 | 2013-10-10 |  | 0d |  |  | Waterworks Plumbing PM | 80h |

| ID | WBS | Task | Duration | Start | Finish | Predecessors | Total slack | Free slack | Resources | Work |
| --- | --- | --- | --- | --- | --- | --- | --- | --- | --- | --- |
| 25 | 7 | **Building Permits** | 10d | 2013-09-30 | 2013-10-10 |  | 0d |  |  | 80h |
| 26 | 7.1 | Obtain Building Permit | 10d | 2013-09-30 | 2013-10-10 |  | 0d |  | East Side Framing & Drywall PM | 80h |
| 27 | 8 | **Framing** | 24d | 2013-10-10 | 2013-11-07 |  | 0d |  |  | 192h |
| 28 | 8.1 | Framing-Order Supplies | 3d | 2013-10-10 | 2013-10-14 | 22, 24, 26 | 0d |  | East Side Framing & Drywall PM | 24h |
| 29 | 8.2 | Framing-Build | 15d | 2013-10-14 | 2013-10-31 | 28 | 0d |  | East Side Framing & Drywal | 120h |
| 30 | 8.3 | Framing-Inspect | 5d | 2013-10-31 | 2013-11-06 | 29 | 0d |  | City & County | 40h |
| 31 | 8.4 | Framing-Project Sign-off | 1d | 2013-11-06 | 2013-11-07 | 30 | 0d |  | Project Manager | 8h |
| 32 | 9 | **Electrical** | 19d | 2013-11-07 | 2013-11-28 |  | 0d |  |  | 152h |
| 33 | 9.1 | Electrical-Order Supplies | 3d | 2013-11-07 | 2013-11-11 | 31 | 0d |  | Sparks Electrical PM | 24h |
| 34 | 9.2 | Electrical-Install | 10d | 2013-11-11 | 2013-11-22 | 33 | 0d |  | Sparks Electrical | 80h |
| 35 | 9.3 | Electrical-Inspect | 5d | 2013-11-22 | 2013-11-27 | 34 | 0d |  | City & County | 40h |
| 36 | 9.4 | Electrical-Project Sign-off | 1d | 2013-11-28 | 2013-11-28 | 35 | 65d |  | Project Manager | 8h |
| 37 | 10 | **Plumbing** | 19d | 2013-11-07 | 2013-11-28 |  | 0d |  |  | 152h |
| 38 | 10.1 | Plumbing-Order Supplies | 3d | 2013-11-07 | 2013-11-11 | 31 | 0d |  | Waterworks Plumbing PM | 24h |
| 39 | 10.2 | Plumbing-Install | 10d | 2013-11-11 | 2013-11-22 | 38 | 0d |  | Waterworks Plumbing | 80h |
| 40 | 10.3 | Plumbing-Inspect | 5d | 2013-11-22 | 2013-11-27 | 39 | 0d |  | City & County | 40h |
| 41 | 10.4 | Plumbing-Project Sign-off | 1d | 2013-11-28 | 2013-11-28 | 40 | 65d |  | Project Manager | 8h |
| 42 | 11 | **Drywall** | 24d | 2013-11-28 | 2013-12-25 |  | 0d |  |  | 192h |
| 43 | 11.1 | Drywall-Order Supplies | 3d | 2013-11-28 | 2013-11-30 | 35, 40 | 0d |  | East Side Framing & Drywall PM | 24h |
| 44 | 11.2 | Drywall-Install | 15d | 2013-11-30 | 2013-12-18 | 43 | 0d |  | East Side Framing & Drywall | 120h |
| 45 | 11.3 | Drywall-Inspect | 5d | 2013-12-18 | 2013-12-24 | 44 | 0d |  | City & County | 40h |
| 46 | 11.4 | Drywall-Project Sign-off | 1d | 2013-12-24 | 2013-12-25 | 45 | 42d |  | Project Manager | 8h |
| 47 | 12 | **Finish Work** | 24d | 2013-12-24 | 2014-01-20 |  | -99d | 0d |  | 192h |
| 48 | 12.1 | Finish-Order Supplies | 3d | 2013-12-24 | 2013-12-27 | 45 | 0d |  | Woodcraft Carpentry PM | 24h |
| 49 | 12.2 | Finish-Install | 15d | 2013-12-27 | 2014-01-14 | 48 | 0d |  | Woodcraft Carpentry | 120h |
| 50 | 12.3 | Finish-Inspect | 5d | 2014-01-14 | 2014-01-18 | 49 | 0d |  | City & County | 40h |
| 51 | 12.4 | Finish-Project Sign-off | 1d | 2014-01-20 | 2014-01-20 | 50 | 0d |  | Project Manager | 8h |

| ID | WBS | Task | Duration | Start | Finish | Predecessors | Total slack | Free slack | Constraint | Resources | Work |
| --- | --- | --- | --- | --- | --- | --- | --- | --- | --- | --- | --- |
| 52 | 13 | **Workbenches** | 20d | 2013-09-30 | 2013-10-22 |  | 0d |  |  |  | 160h |
| 53 | 13.1 | Workbenches-Order Supplies | 2d | 2013-09-30 | 2013-10-01 | 51 | -99d | 0d | finish no later than 2013-10-01 | Student Workers Manage | 16h |
| 54 | 13.2 | Workbenches-Build | 15d | 2013-10-02 | 2013-10-18 | 53 | 85d | 0d | finish no later than 2014-01-23 | Student Workers | 120h |
| 55 | 13.3 | Workbenches-Quality inspection | 2d | 2013-10-18 | 2013-10-21 | 54 | 98d | 0d |  | Project Manager | 16h |
| 56 | 13.4 | Workbenches-Project Sign-off | 1d | 2013-10-21 | 2013-10-22 | 55 | 98d |  |  | Project Manager | 8h |
| 57 | 14 | **Equipment Packing** | 3d | 2014-01-21 | 2014-01-23 |  | 0d |  |  |  | 40h |
| 58 | 14.1 | Pack production equipment | 2d | 2014-01-21 | 2014-01-22 | 51 | 17d |  |  | City Equipment Movers PM | 16h |
| 59 | 14.2 | Pack non-production equipment | 2d | 2014-01-21 | 2014-01-22 | 51 | 0d |  |  | City Equipment Movers | 16h |
| 60 | 14.3 | Project Sign-off | 1d | 2014-01-23 | 2014-01-23 | 59 | 0d |  |  | Project Manager | 8h |
| 61 | 15 | **Move** | 4d | 2014-01-24 | 2014-01-28 |  | 0d |  |  |  | 56h |
| 62 | 15.1 | Move production equipment | 3d | 2014-01-24 | 2014-01-27 | 60 | 0d |  |  | Express Moving Company PM | 24h |
| 63 | 15.2 | Move non-production equipment | 3d | 2014-01-24 | 2014-01-27 | 60 | 0d |  |  | Express Moving Company | 24h |
| 64 | 15.3 | Project Sign-off | 1d | 2014-01-27 | 2014-01-28 | 62, 63 | 0d |  |  | Project Manager | 8h |
| 65 | 16 | **Procurement Closure** | 5d | 2014-01-28 | 2014-02-03 |  | 0d |  |  |  | 40h |
| 66 | 16.1 | Review contract work | 3d | 2014-01-28 | 2014-01-31 | 64 | 0d |  |  | Project Manager | 24h |
| 67 | 16.2 | Release contractors | 1d | 2014-01-31 | 2014-02-01 | 66 | 0d |  |  | Project Manager | 8h |
| 68 | 16.3 | Pay contractors | 1d | 2014-02-01 | 2014-02-03 | 67 | 0d |  |  | Project Manager | 8h |
| 69 | 17 | **Project Closure** | 7d | 2014-02-03 | 2014-02-11 |  | 0d |  |  |  | 56h |
| 70 | 17.1 | Final report | 3d | 2014-02-03 | 2014-02-06 | 68 | 0d |  |  | Project Manager | 24h |
| 71 | 17.2 | Archive documentation | 3d | 2014-02-06 | 2014-02-10 | 70 | 0d |  |  | Project Manager | 24h |
| 72 | 17.3 | Lessons Learned | 1d | 2014-02-10 | 2014-02-11 | 71 | 0d |  |  | Project Manager | 8h |
